# План выполнения работ, ред. 01

Schedule from MS Project, 2011-06-14 to 2011-12-01, costs in р..
***

## Calendars

- Стандартный: Mon-Fri 09:00-13:00, 14:00-18:00; Sat-Sun off.

## Resources

| Resource | Rate |
| --- | --- |
| Руководитель проекта | 400 |
| Постановщик задач исполнителя 2 | 300 |
| Разработчик системы 1 | 350 |
| Разработчик системы 2 | 350 |
| Разработчик системы 3 | 350 |
| Архитектор системы | 350 |
| Постановщик задач исполнителя 1 | 150 |
| Технический специалист | 300 |
| Специалист по внедрению | 200 |
| Разработчик документации | 250 |
| Архитектор системы, |  |

## Schedule

| ID | WBS | Task | Duration | Start | Finish | Predecessors | Total slack | Free slack | Constraint | Resources | Work | Cost |
| --- | --- | --- | --- | --- | --- | --- | --- | --- | --- | --- | --- | --- |
| 1 | 1 | **Разработка автоматизированной информационной системы «Балтик-Лайт»** | 123d | 2011-06-14 | 2011-12-01 |  | 0d |  |  |  | 1920h | 519,920 |
| 2 | 1.1 | **Этап 1. Запуск подсистемы "Прием, обработка и согласование заявок от клиентов, расчет себестоимости"** | 47d | 2011-06-14 | 2011-08-17 |  | 0d |  |  |  | 920h | 260,640 |
| 3 | 1.1.1 | Формирование необходимых структур и словарей для БД | 4d | 2011-06-14 | 2011-06-17 |  | 0d |  | start no earlier than 2011-06-14 | Архитектор системы; Постановщик задач исполнителя 1 | 64h | 16,000 |
| 4 | 1.1.2 | Организация наполнения справочных данных по подсистеме "Прием, обработка и согласование заявок от клиентов, расчет себестоимости". Сотрудники и тарифные ставки, Классификатор товаров и услуг | 4d | 2011-06-20 | 2011-06-23 | 3 | 111d | 0d |  | Постановщик задач исполнителя 1; Технический специалист | 64h | 14,400 |
| 5 | 1.1.3 | Загрузка прайс-листов поставщика FORDA | 4d | 2011-06-24 | 2011-06-29 | 4 | 111d |  |  | Технический специалист | 32h | 9,600 |
| 6 | 1.1.4 | **Разработка требуемой функциональности для подсистемы "Прием, обработка и согласование заявок от клиентов, расчет себестоимости", в т.ч.:** | 26d | 2011-06-20 | 2011-07-25 |  | 0d |  |  | Архитектор системы [20%]; Постановщик задач исполнителя 1 [30%]; Разработчик системы 1 | 624h | 193,440 |
| 7 | 1.1.4.1 | 1.1. Функциональность бизнес-процесса первичного приема Заявок от клиентов, пп 2.1 ТЗ | 3d | 2011-06-20 | 2011-06-22 | 3 | 0d |  |  | Архитектор системы [20%]; Постановщик задач исполнителя 1 [30%]; Разработчик системы 1 | 36h | 11,160 |
| 8 | 1.1.4.2 | 1.2. Функциональность учета клиентов – юридических и физических лиц, пп 2.2 ТЗ | 1d | 2011-06-23 | 2011-06-23 | 7 | 0d |  |  | Архитектор системы [20%]; Постановщик задач исполнителя 1 [30%]; Разработчик системы 1 | 12h | 3,720 |
| 9 | 1.1.4.3 | 1.3. Функциональность бизнес-процесса технологической обработки заявок, формирования типовых договоров и ТЗ к ним, алгоритмы расчета себестоимости, пп 2.3 ТЗ | 12d | 2011-06-24 | 2011-07-11 | 8 | 0d |  |  | Архитектор системы [20%]; Постановщик задач исполнителя 1 [30%]; Разработчик системы 1 | 144h | 44,640 |
| 10 | 1.1.4.4 | 1.4. Функциональность бизнес-процессов организации системы календарного планирования, напоминаний, формирования и контроля исполнения задач и поручений, пп 2.9 ТЗ | 10d | 2011-07-12 | 2011-07-25 | 9 | 0d |  |  | Архитектор системы [20%]; Постановщик задач исполнителя 1 [30%]; Разработчик системы 1 | 120h | 37,200 |
| 11 | 1.1.5 | Разработка необходимых бланков печатных форм в части подсистемы "Прием, обработка и согласование заявок от клиентов, расчет себестоимости" | 5d | 2011-07-26 | 2011-08-01 | 10 | 0d |  |  | Специалист по внедрению | 40h | 8,000 |
| 12 | 1.1.6 | Тестовая эксплуатация системы в части подсистемы "Прием, обработка и согласование заявок от клиентов, расчет себестоимости" | 2d | 2011-08-02 | 2011-08-03 | 11 | 0d |  |  | Специалист по внедрению | 16h | 3,200 |
| 13 | 1.1.7 | Внедрение подсистемы на рабочих местах | 10d | 2011-08-04 | 2011-08-17 | 12 | 0d |  |  | Специалист по внедрению | 80h | 16,000 |
| 14 | 1.2 | **Этап 2. Запуск подсистемы "Закупка сырья и материалов"** | 12d | 2011-08-18 | 2011-09-02 |  | 0d |  |  |  | 124h | 30,360 |
| 15 | 1.2.1 | Формирование необходимых структур, классификаторов и словарей для БД | 2d | 2011-08-18 | 2011-08-19 | 13 | 0d |  | start no earlier than 2011-06-06 | Архитектор системы; Постановщик задач исполнителя 1 | 32h | 8,000 |
| 16 | 1.2.2 | Разработка необходимых бланков печатных форм в части подсистемы "Закупка сырья и материалов" | 3d | 2011-08-22 | 2011-08-24 | 15 | 0d |  |  | Специалист по внедрению | 24h | 4,800 |
| 17 | 1.2.3 | Разработка требуемой функциональности для подсистемы "Закупка сырья и материалов", пп 2.4 ТЗ | 3d | 2011-08-25 | 2011-08-29 | 16 | 0d |  |  | Архитектор системы [20%]; Постановщик задач исполнителя 1 [30%]; Разработчик системы 1 | 36h | 11,160 |
| 18 | 1.2.4 | Тестовая эксплуатация системы в части подсистемы "Закупка сырья и материалов" | 2d | 2011-08-30 | 2011-08-31 | 17 | 0d |  |  | Специалист по внедрению | 16h | 3,200 |
| 19 | 1.2.5 | Внедрение подсистемы на рабочих местах | 2d | 2011-09-01 | 2011-09-02 | 18 | 0d |  |  | Специалист по внедрению | 16h | 3,200 |
| 20 | 1.3 | **Этап 3. Запуск подсистемы "Производство готовой продукции"** | 16d | 2011-09-05 | 2011-09-26 |  | 0d |  |  |  | 172h | 43,400 |
| 21 | 1.3.1 | Формирование необходимых структур, классификаторов и словарей для БД | 3d | 2011-09-05 | 2011-09-07 | 19 | 0d |  | start no earlier than 2011-06-06 | Архитектор системы; Постановщик задач исполнителя 1 | 48h | 12,000 |
| 22 | 1.3.2 | Разработка необходимых бланков печатных форм в части подсистемы "Производство готовой продукции" | 2d | 2011-09-08 | 2011-09-09 | 21 | 0d |  |  | Специалист по внедрению | 16h | 3,200 |
| 23 | 1.3.3 | Разработка требуемой функциональности для подсистемы "Производство готовой продукции", пп 2.5 ТЗ | 5d | 2011-09-12 | 2011-09-16 | 22 | 0d |  |  | Архитектор системы [20%]; Постановщик задач исполнителя 1 [30%]; Разработчик системы 1 | 60h | 18,600 |
| 24 | 1.3.4 | Тестовая эксплуатация системы в части подсистемы "Производство готовой продукции" | 2d | 2011-09-19 | 2011-09-20 | 23 | 0d |  |  | Специалист по внедрению | 16h | 3,200 |
| 25 | 1.3.5 | Внедрение подсистемы на рабочих местах | 4d | 2011-09-21 | 2011-09-26 | 24 | 0d |  |  | Специалист по внедрению | 32h | 6,400 |

| ID | WBS | Task | Duration | Start | Finish | Predecessors | Total slack | Free slack | Constraint | Resources | Work | Cost |
| --- | --- | --- | --- | --- | --- | --- | --- | --- | --- | --- | --- | --- |
| 26 | 1.4 | **Этап 4. Запуск подсистемы "Организация и учет взаиморасчетов с клиентами, поставщиками и субподрядными организациями"** | 25d | 2011-09-27 | 2011-10-31 |  | 0d |  |  |  | 272h | 70,800 |
| 27 | 1.4.1 | Формирование необходимых структур, классификаторов и словарей для БД | 4d | 2011-09-27 | 2011-09-30 | 25 | 0d |  | start no earlier than 2011-06-06 | Архитектор системы; Постановщик задач исполнителя 1 | 64h | 16,000 |
| 28 | 1.4.2 | Разработка необходимых бланков печатных форм в части подсистемы "Организация и учет взаиморасчетов с клиентами, поставщиками и субподрядными организациями" | 4d | 2011-10-03 | 2011-10-06 | 27 | 0d |  |  | Специалист по внедрению | 32h | 6,400 |
| 29 | 1.4.3 | Разработка требуемой функциональности для подсистемы "Организация и учет взаиморасчетов с клиентами, поставщиками и субподрядными организациями", пп 2.8 ТЗ | 10d | 2011-10-07 | 2011-10-20 | 28 | 0d |  |  | Архитектор системы [20%]; Постановщик задач исполнителя 1 [30%]; Разработчик системы 1 | 120h | 37,200 |
| 30 | 1.4.4 | Тестовая эксплуатация системы в части подсистемы "Организация и учет взаиморасчетов с клиентами, поставщиками и субподрядными организациями" | 2d | 2011-10-21 | 2011-10-24 | 29 | 0d |  |  | Специалист по внедрению | 16h | 3,200 |
| 31 | 1.4.5 | Внедрение подсистемы на рабочих местах | 5d | 2011-10-25 | 2011-10-31 | 30 | 0d |  |  | Специалист по внедрению | 40h | 8,000 |
| 32 | 1.5 | **Этап 5. Запуск подсистемы "Обеспечение транспортной деятельности и монтажных работ"** | 11d | 2011-11-01 | 2011-11-15 |  | 0d |  |  |  | 168h | 45,760 |
| 33 | 1.5.1 | Формирование необходимых структур, классификаторов и словарей для БД | 2d | 2011-11-01 | 2011-11-02 | 31 | 0d |  | start no earlier than 2011-06-06 | Архитектор системы; Постановщик задач исполнителя 1 | 32h | 8,000 |
| 34 | 1.5.2 | Разработка необходимых бланков печатных форм в части подсистемы "Обеспечение транспортной деятельности и монтажных работ" | 1d | 2011-11-03 | 2011-11-03 | 33 | 0d |  |  | Специалист по внедрению | 8h | 1,600 |
| 35 | 1.5.3 | **Разработка требуемой функциональности для подсистемы "Обеспечение транспортной деятельности и монтажных работ"** | 4d | 2011-11-04 | 2011-11-09 | 34 | 0d |  |  | Архитектор системы [20%]; Постановщик задач исполнителя 1 [30%]; Разработчик системы 1 | 96h | 29,760 |
| 36 | 1.5.3.1 | 5.1. Функциональность бизнес-процесса обеспечения транспортной деятельности, пп 2.6 ТЗ | 3d | 2011-11-04 | 2011-11-08 |  | 0d |  |  | Архитектор системы [20%]; Постановщик задач исполнителя 1 [30%]; Разработчик системы 1 | 36h | 11,160 |
| 37 | 1.5.3.2 | 5.2. Функциональность бизнес-процесса учета выполнения монтажных работ, пп 2.7 ТЗ | 1d | 2011-11-09 | 2011-11-09 | 36 | 0d |  |  | Архитектор системы [20%]; Постановщик задач исполнителя 1 [30%]; Разработчик системы 1 | 12h | 3,720 |
| 38 | 1.5.4 | Тестовая эксплуатация системы в части подсистемы "Обеспечение транспортной деятельности и монтажных работ" | 2d | 2011-11-10 | 2011-11-11 | 37 | 0d |  |  | Специалист по внедрению | 16h | 3,200 |
| 39 | 1.5.5 | Внедрение подсистемы на рабочих местах | 2d | 2011-11-14 | 2011-11-15 | 38 | 0d |  |  | Специалист по внедрению | 16h | 3,200 |
| 40 | 1.6 | **Этап 6. Запуск подсистемы "Формирование аналитических отчетов"** | 12d | 2011-11-16 | 2011-12-01 |  | 0d |  |  |  | 136h | 38,560 |
| 41 | 1.6.1 | Формирование необходимых структур, классификаторов и словарей для БД | 1d | 2011-11-16 | 2011-11-16 | 39 | 0d |  | start no earlier than 2011-06-06 | Архитектор системы; Постановщик задач исполнителя 1 | 16h | 4,000 |
| 42 | 1.6.2 | Разработка требуемой функциональности для подсистемы "Формирование аналитических отчетов", пп 2.11 ТЗ | 8d | 2011-11-17 | 2011-11-28 | 41 | 0d |  |  | Архитектор системы [20%]; Постановщик задач исполнителя 1 [30%]; Разработчик системы 1 | 96h | 29,760 |
| 43 | 1.6.3 | Тестовая эксплуатация системы в части подсистемы "Формирование аналитических отчетов" | 3d | 2011-11-29 | 2011-12-01 | 42 | 0d |  |  | Специалист по внедрению | 24h | 4,800 |
| 44 | 1.7 | **Этап 7. Обучение и запуск Системы в целом в опытно-промышленную эксплуатацию** | 10d | 2011-11-14 | 2011-11-25 |  | 4d |  |  |  | 128h | 30,400 |
| 45 | 1.7.1 | Подготовка инструкций для всех ролей пользователей | 6d | 2011-11-14 | 2011-11-21 | 38 | 4d | 0d | start no earlier than 2011-06-06 | Архитектор системы; Постановщик задач исполнителя 1 | 96h | 24,000 |
| 46 | 1.7.2 | Тестовая эксплуатация системы в целом и запуск в промышленную эксплуатацию | 4d | 2011-11-22 | 2011-11-25 | 45 | 4d |  |  | Специалист по внедрению | 32h | 6,400 |
